# State Medicaid Agency ICD-10 Timeline

Schedule from MS Project, 2010-09-01 to 2014-03-30.

## Calendars

- Standard: Mon-Fri 08:00-12:00, 13:00-17:00; Sat-Sun off. Exceptions (off unless hours are given): 2011-01-01 08:00-12:00, 13:00-17:00.

## Schedule

| ID | WBS | Task | Type | Duration | Start | Finish | Predecessors | Total slack | Free slack | Constraint |
| --- | --- | --- | --- | --- | --- | --- | --- | --- | --- | --- |
| 1 | 1 | **State Medicaid Agency ICD-10 Implementation** |  | 933.94d | 2010-09-01 | 2014-03-30 |  | 0d |  |  |
| 2 | 1.1 | **Critical Dependencies** |  | 0d | 2011-01-01 | 2011-01-01 |  | 845d |  |  |
| 3 | 1.1.1 | Track 5010 (Compliance Date: January 1, 2012) | milestone | 0d | 2011-01-01 | 2011-01-01 |  | 845d |  | finish no earlier than 2011-01-01 |
| 4 | 1.2 | Milestone: Start Program | milestone | 0d | 2010-09-01 | 2010-09-01 |  | 1d | 0d | start no earlier than 2010-09-01 |
| 5 | 1.3 | **Awareness** |  | 923d | 2010-09-01 | 2014-03-14 |  | 10.94d |  |  |
| 6 | 1.3.1 | **Internal Awareness, Communication, and Education/Training** |  | 923d | 2010-09-01 | 2014-03-14 |  | 10.94d |  |  |
| 7 | 1.3.1.1 | Provide Awareness Training to ICD-10 Leadership and ICD-10 Team |  | 3emo | 2010-09-01 | 2010-11-30 | 4 | 48d | 0d |  |
| 8 | 1.3.1.2 | Educate and Train Staff (including training during transition and implementation) |  | 40emo | 2010-11-30 | 2014-03-14 | 7 | 48d |  |  |
| 9 | 1.3.2 | **External Awareness, Communications, and Outreach** |  | 859d | 2010-11-30 | 2014-03-14 |  | 10.94d |  |  |
| 10 | 1.3.2.1 | Conduct Communications with State Entities/Trading Partners/Providers/Contractors/Vendors |  | 40emo | 2010-11-30 | 2014-03-14 | 7 | 48d |  |  |
| 11 | 1.3.2.2 | Monitor Trading Partner ICD-10 Transition Status |  | 39emo | 2010-12-30 | 2014-03-14 | 25 | 48d |  |  |
| 12 | 1.3.2.3 | Identify and Leverage Partnering/Outreach Opportunities (with providers, advisory boards, etc.) |  | 40emo | 2010-11-30 | 2014-03-14 | 7 | 48d |  |  |
| 13 | 1.4 | **Assessment** |  | 193.94d | 2010-09-01 | 2011-05-29 |  | 1d |  |  |
| 14 | 1.4.1 | **High-level planning for ICD-10 activities** |  | 42.94d | 2010-09-01 | 2010-10-31 |  | 1d |  |  |
| 15 | 1.4.1.1 | Establish an Executive Sponsorship, ICD-10 Steering Committee, ICD-10 Point of Contact |  | 1emo | 2010-09-01 | 2010-10-01 | 4 | 3d | 0d |  |
| 16 | 1.4.1.2 | Establish and Organize Impact Assessment Team |  | 1emo | 2010-09-01 | 2010-10-01 | 15SS | 3d | 0d |  |
| 17 | 1.4.1.3 | Review/Establish Program Management Office and Governance Structure |  | 1emo | 2010-10-01 | 2010-10-31 | 15 | 3738d | 450d |  |
| 18 | 1.4.2 | Develop Tools/Processes to Facilitate Assessment Activities |  | 3emo | 2010-09-01 | 2010-11-30 | 15SS, 16SS | 3648d |  |  |
| 19 | 1.4.3 | **Perform Impact Assessment** |  | 64d | 2010-10-01 | 2010-12-30 |  | 0.94d |  |  |
| 20 | 1.4.3.1 | Identify Policies Impacted by ICD-10 |  | 3emo | 2010-10-01 | 2010-12-30 | 16 | 48d | 0d |  |
| 21 | 1.4.3.2 | Identify Processes Impacted by ICD-10 |  | 3emo | 2010-10-01 | 2010-12-30 | 16 | 48d | 0d |  |
| 22 | 1.4.3.3 | Identify Systems Impacted by ICD-10 |  | 3emo | 2010-10-01 | 2010-12-30 | 16 | 48d | 0d |  |
| 23 | 1.4.3.4 | Identify Impacts of ICD-10 on Trading Partners/Providers/Contractors/Vendors Relations |  | 3emo | 2010-10-01 | 2010-12-30 | 16 | 3d | 0d |  |
| 24 | 1.4.3.5 | Document and Communicate Impact Assessment Findings |  | 1emo | 2010-11-30 | 2010-12-30 | 23SS+2emo | 3d | 0d |  |
| 25 | 1.4.3.6 | Milestone: Impact Assessment Completed | milestone | 0d | 2010-12-30 | 2010-12-30 | 24, 20, 21, 22, 23 | 12.94d | 0d |  |
| 26 | 1.4.3.7 | Determine Administrative Budget for DDI and O&M |  | 1emo | 2010-11-30 | 2010-12-30 | 24SS | 3d | 0d |  |

Notes:
- 3: Track 5010 (Compliance Date: January 1, 2012)
- 7: Provide Awareness Training to ICD-10 Leadership and ICD-10 Team
- 8: Educate and Train Staff (including training during transition and implementation)
- 10: Conduct Communications with State Entities/Trading Partners/Providers/Contractors/Vendors
- 11: Monitor Trading Partner ICD-10 Transition Status
- 12: Identify and Leverage Partnering/Outreach Opportunities (with providers, advisory boards, etc.)
- 15: Establish an Executive Sponsorship, ICD-10 Steering Committee, ICD-10 Pont of Contact
- 16: Establish and Organize Impact Assessment Team
- 17: Review/Establish Program Management Office and Governance Structure
- 18: Develop Tools/Processes to Facilitate Assessment Activities
- 20: Identify Policies Impacted by ICD-10
- 21: Identify Processes Impacted by ICD-10
- 22: Identify Systems Impacted by ICD-10
- 23: Identify Impacts of ICD-10 on Trading Partners/Providers/Contractors/Vendors Relations
- 24: Document and Communicate Impact Assessment Findings
- 26: Determine Administrative Budget for DDI and O&M

| ID | WBS | Task | Type | Duration | Start | Finish | Predecessors | Total slack | Free slack |
| --- | --- | --- | --- | --- | --- | --- | --- | --- | --- |
| 27 | 1.4.4 | **Develop Remediation Strategy/Plan** |  | 107.94d | 2010-12-30 | 2011-05-29 |  | 1d |  |
| 28 | 1.4.4.1 | Create and Receive Approval of Remediation Strategy for Policies, Processes, and Systems (including Cross-Walking and Mapping Strategies) |  | 3emo | 2010-12-30 | 2011-03-30 | 26 | 3d | 0d |
| 29 | 1.4.4.2 | Create End-to-End Testing Strategy |  | 1emo | 2011-02-28 | 2011-03-30 | 28SS+2emo | 3108d | 0d |
| 30 | 1.4.4.3 | Milestone: Core ICD-10 Strategies Developed | milestone | 0d | 2011-03-30 | 2011-03-30 | 29, 28 | 740d | 0d |
| 31 | 1.4.4.4 | **Develop Financial Plans** |  | 64.94d | 2011-02-28 | 2011-05-29 |  | 1d |  |
| 32 | 1.4.4.4.1 | Forecast Claims Payments with ICD-10 Codes |  | 1emo | 2011-02-28 | 2011-03-30 | 28SS+2emo | 3288d |  |
| 33 | 1.4.4.4.2 | Develop and Execute Resource Acquisition Plan |  | 3emo | 2011-02-28 | 2011-05-29 | 28SS+2emo | 3108d |  |
| 34 | 1.4.4.4.3 | Develop Advanced Planning Documents (APDs), and Coordinate APD Approvals |  | 3emo | 2011-02-28 | 2011-05-29 | 28SS+2emo | 3d | 0d |
| 35 | 1.4.4.5 | Establish and Organize Remediation Team |  | 1emo | 2011-02-28 | 2011-03-30 | 30SS-1emo | 3108d | 0d |
| 36 | 1.4.4.6 | Develop Detailed Implementation Plans |  | 2emo | 2011-03-30 | 2011-05-29 | 35 | 3108d |  |
| 37 | 1.5 | **Remediation** |  | 257.06d | 2011-05-29 | 2012-05-23 |  | 0.06d |  |
| 38 | 1.5.1 | Develop Updates to Policies |  | 3emo | 2011-05-29 | 2011-08-27 | 34SS+3emo | 2838d | 810d |
| 39 | 1.5.2 | Develop Updates to Processes |  | 3emo | 2011-05-29 | 2011-08-27 | 34SS+3emo | 2838d | 810d |
| 40 | 1.5.3 | **IT Changes** |  | 257.06d | 2011-05-29 | 2012-05-23 |  | 0.06d |  |
| 41 | 1.5.3.1 | Develop System Requirements and Change Requests |  | 3emo | 2011-05-29 | 2011-08-27 | 34SS+3emo | 3d | 0d |
| 42 | 1.5.3.2 | Design System Changes |  | 2emo | 2011-08-27 | 2011-10-26 | 41 | 3d | 0d |
| 43 | 1.5.3.3 | Develop System Changes |  | 6emo | 2011-10-26 | 2012-04-23 | 42 | 3d | 0d |
| 44 | 1.5.3.4 | Perform System Tests for Each System |  | 2emo | 2012-03-24 | 2012-05-23 | 43SS+5emo | 2028d | 0d |
| 45 | 1.5.4 | Milestone: ICD-10 Changes Completed | milestone | 0d | 2012-05-23 | 2012-05-23 | 38, 39, 41, 42, 43, 44 | 482.94d |  |
| 46 | 1.6 | **End-to-End Testing** |  | 353d | 2012-02-23 | 2013-07-02 |  | 1d |  |
| 47 | 1.6.1 | Develop Test Plans and Test Data |  | 2emo | 2012-02-23 | 2012-04-23 | 43SS+4emo | 3d | 0d |
| 48 | 1.6.2 | Test Internally: End-to-End - Level I Testing |  | 6emo | 2012-04-23 | 2012-10-20 | 47 | 3d | 0d |
| 49 | 1.6.3 | Test Externally: Partner End-to-End - Level II Testing |  | 9emo | 2012-10-05 | 2013-07-02 | 48SS+5.5emo | 3d | 0d |
| 50 | 1.6.4 | Milestone: End-to-End Testing of ICD-10 Completed | milestone | 0d | 2013-07-02 | 2013-07-02 | 47, 48, 49 | 193.94d |  |

Notes:
- 28: Create and Receive Approval of Remediation Strategy for Policies, Processes, and Systems (including Cross-walking and Mapping Strategies)
- 29: Create End-to-End Testing Strategy
- 32: Estimate Financial Impacts of ICD-10 on SMA Payments to Providers
- 33: Develop and Execute Resource Acquisition Plan
- 34: Develop Advanced Planning Documents (APDs), and Coordinate APD Approvals
- 35: Establish and Organize Remediation Team
- 36: Develop Detailed Implementation Plans
- 38: Develop Updates to Policies
- 39: Develop Updates to Processes
- 41: Develop System Requirements and Change Requests
- 42: Design System Changes
- 43: Develop System Changes
- 44: Test System Changes
- 47: Develop Test Plans and Test Data
- 48: Test Internally End-to-End - Level I Testing
- 49: Test Externally Partner End-to-End - Level II Testing

| ID | WBS | Task | Type | Duration | Start | Finish | Predecessors | Total slack | Constraint |
| --- | --- | --- | --- | --- | --- | --- | --- | --- | --- |
| 51 | 1.7 | **Transition** |  | 256.94d | 2013-04-04 | 2014-03-30 |  | 0d |  |
| 52 | 1.7.1 | Publish Final Rule and Sub-regulatory Policy Updates |  | 6emo | 2013-04-04 | 2013-10-01 | 55FS-6emo | 0d |  |
| 53 | 1.7.2 | Publish Final Rule and Sub-regulatory Process Updates |  | 6emo | 2013-04-04 | 2013-10-01 | 55FS-6emo | 0d |  |
| 54 | 1.7.3 | Transition and Implement System Changes |  | 3emo | 2013-07-03 | 2013-10-01 | 49, 52SS+3emo, 53SS+3emo | 0d |  |
| 55 | 1.7.4 | Milestone: ICD-10 Implemented and Live | milestone | 0d | 2013-10-01 | 2013-10-01 |  | 0d | start no earlier than 2013-10-01 |
| 56 | 1.7.5 | **Post Transition Support** |  | 192.94d | 2013-07-03 | 2014-03-30 |  | 0d |  |
| 57 | 1.7.5.1 | Provide Customer Support |  | 6emo | 2013-07-03 | 2013-12-30 | 54SS | 270d |  |
| 58 | 1.7.5.2 | Monitor Operations |  | 9emo | 2013-07-03 | 2014-03-30 | 54SS | 0d |  |

Notes:
- 52: Publish Final Rule and Sub-regulatory Policy Updates
- 53: Publish Final Rule and Sub-regulatory Process Updates
- 54: Transition and Implement System Changes
- 57: Provide Customer Support
- 58: Monitor Operations
